# HRA Project Plan

Schedule from MS Project, 2011-10-31 to 2012-12-14, A marks actual dates.
Microsoft

## Calendars

- Standard: Mon-Fri 08:00-12:00, 13:00-17:00; Sat-Sun off. Exceptions (off unless hours are given): 2011-11-24 (Thanksgiving Day), 2011-11-25 (Thanksgiving Friday), 2011-12-23 (Special MIT Holiday 1), 2011-12-26 (Christmas Day Observed), 2011-12-30 (Special MIT Holiday 2), 2012-01-02 (New Years Day Observed), 2012-01-16 (Martin Luther King Birthday), 2012-02-20 (Presidents Day).

## Resources

| Resource |
| --- |
| Ross |
| Jonathan |
| Robin |
| Janet |

## Schedule

| ID | WBS | Task | Type | Duration | Start | Finish | Predecessors | Complete | Remaining | Total slack | Constraint | Resources | Work | Actual work |
| --- | --- | --- | --- | --- | --- | --- | --- | --- | --- | --- | --- | --- | --- | --- |
| 1 | 1 | **Housing Replacement Analysis Project** |  | 287d | 2011-10-31 A | 2012-12-14 |  | 42% | 167.59d | 0d |  |  | 1710.8h | 1082.64h |
| 2 | 1.1 | Project Kickoff Meeting |  | 1d | 2011-10-31 | 2011-10-31 |  |  |  | 305.5d |  |  |  |  |
| 3 | 1.2 | **Discovery Phase (as-is)** |  | 183d | 2011-11-04 A | 2012-07-27 |  | 55% | 82.05d | 100d |  |  | 1710.8h | 1082.64h |
| 4 | 1.2.1 | **Business Justification** |  | 20d | 2011-11-04 A | 2011-12-06 A | 2 | 100% |  |  |  |  | 136h | 136h |
| 5 | 1.2.1.1 | Write Business Justification |  | 10d | 2011-11-14 A | 2011-11-25 A | 6 | 100% |  |  | start no earlier than 2011-11-01 | Jonathan | 80h | 80h |
| 6 | 1.2.1.2 | Review Business Justification |  | 6d | 2011-11-04 A | 2011-11-11 A |  | 100% |  |  | finish no earlier than 2011-11-11 | Jonathan | 48h | 48h |
| 7 | 1.2.1.3 | Obtain Approval from Project Team |  | 1d | 2011-11-29 A | 2011-11-29 A | 5, 6 | 100% |  |  | start no earlier than 2011-11-29 | Jonathan | 8h | 8h |
| 8 | 1.2.1.4 | Obtain Approval from Project Sponsors | milestone | 0d | 2011-12-06 A | 2011-12-06 A | 7 | 100% |  |  | start no earlier than 2011-12-06 | Jonathan |  |  |
| 9 | 1.2.1.5 | Business Justification completed | milestone | 0d | 2011-12-06 A | 2011-12-06 A | 8 | 100% |  |  |  | Jonathan |  |  |
| 10 | 1.2.2 | **Project Scope Document** |  | 19d | 2011-11-07 A | 2011-12-06 A | 2 | 100% |  |  |  |  | 56h | 56h |
| 11 | 1.2.2.1 | Write Project Scope Document |  | 5d | 2011-11-07 A | 2011-11-11 A |  | 100% |  |  | finish no earlier than 2011-11-11 | Jonathan | 40h | 40h |
| 12 | 1.2.2.2 | Review Project Scope Document |  | 1d | 2011-11-18 A | 2011-11-18 A | 11 | 100% |  |  | finish no earlier than 2011-11-18 | Jonathan | 8h | 8h |
| 13 | 1.2.2.3 | Obtain Approval from Project Team |  | 1d | 2011-11-29 A | 2011-11-29 A |  | 100% |  |  | start no earlier than 2011-11-29 | Jonathan | 8h | 8h |
| 14 | 1.2.2.4 | Obtain Approval from Project Sponsors | milestone | 0d | 2011-12-06 A | 2011-12-06 A |  | 100% |  |  | start no earlier than 2011-12-06 | Jonathan |  |  |
| 15 | 1.2.2.5 | Project Scope completed | milestone | 0d | 2011-12-06 A | 2011-12-06 A |  | 100% |  |  | start no earlier than 2011-12-06 | Jonathan |  |  |
| 16 | 1.2.3 | **Discovery Meetings** |  | 109d | 2011-12-15 A | 2012-05-23 | 4, 10 | 75% | 27.76d | 147d |  |  | 972.8h | 801.6h |
| 17 | 1.2.3.1 | **Housing / Lottery** |  | 94d | 2011-12-15 A | 2012-05-02 |  | 25% | 70.5d | 162d |  |  | 81.6h | 9.6h |
| 18 | 1.2.3.1.1 | Freshman (new to the Institute) |  | 2d | 2011-12-15 A | 2011-12-16 A |  | 100% |  |  | start no earlier than 2011-12-15 | Ross [40%] | 6.4h | 6.4h |
| 19 | 1.2.3.1.2 | Upperclassman |  | 1d | 2012-04-09 A | 2012-04-09 A |  | 100% |  |  | start no earlier than 2012-04-09 | Ross [40%] | 3.2h | 3.2h |
| 20 | 1.2.3.1.3 | FSILG |  | 1d | 2012-05-02 | 2012-05-02 |  |  |  | 162d | start no earlier than 2012-05-02 | Ross | 8h |  |
| 21 | 1.2.3.1.4 | Off Campus Students |  | 1d | 2012-05-02 | 2012-05-02 |  |  |  | 162d | start no earlier than 2012-05-02 | Ross | 8h |  |
| 22 | 1.2.3.1.5 | Graduate Students |  | 1d | 2012-05-02 | 2012-05-02 |  |  |  | 162d | start no earlier than 2012-05-02 | Ross | 8h |  |
| 23 | 1.2.3.1.6 | Summer Students |  | 1d | 2012-05-02 | 2012-05-02 |  |  |  | 162d | start no earlier than 2012-05-02 | Ross | 8h |  |
| 24 | 1.2.3.1.7 | Post-Doctoral / Faculty |  | 1d | 2012-05-02 | 2012-05-02 |  |  |  | 162d | start no earlier than 2012-05-02 | Ross | 8h |  |
| 25 | 1.2.3.1.8 | Young Students (Legal Minors) |  | 1d | 2012-05-02 | 2012-05-02 |  |  |  | 162d | start no earlier than 2012-05-02 | Ross | 8h |  |
| 26 | 1.2.3.1.9 | Outside, Non Affiliated Groups |  | 1d | 2012-05-02 | 2012-05-02 |  |  |  | 162d | start no earlier than 2012-05-02 | Ross | 8h |  |
| 27 | 1.2.3.1.10 | MIT - Affiliated Groups |  | 1d | 2012-05-02 | 2012-05-02 |  |  |  | 162d | start no earlier than 2012-05-02 | Ross | 8h |  |
| 28 | 1.2.3.1.11 | Visitors |  | 1d | 2012-05-02 | 2012-05-02 |  |  |  | 162d | start no earlier than 2012-05-02 | Ross | 8h |  |

| ID | WBS | Task | Duration | Start | Finish | Predecessors | Complete | Total slack | Free slack | Constraint | Resources | Work | Actual work |
| --- | --- | --- | --- | --- | --- | --- | --- | --- | --- | --- | --- | --- | --- |
| 29 | 1.2.3.2 | **Housing filemaker Databases** | 10d | 2012-02-06 A | 2012-02-17 A |  | 100% |  |  |  |  | 232h | 232h |
| 30 | 1.2.3.2.1 | Master Blaster | 5d | 2012-02-06 A | 2012-02-10 A |  | 100% |  |  | start no earlier than 2012-02-06 | Janet | 40h | 40h |
| 31 | 1.2.3.2.2 | UG Confirmation | 5d | 2012-02-06 A | 2012-02-10 A |  | 100% |  |  | start no earlier than 2012-02-06 | Ross [40%] | 16h | 16h |
| 32 | 1.2.3.2.3 | Conference / Guest | 5d | 2012-02-06 A | 2012-02-10 A |  | 100% |  |  | start no earlier than 2012-02-06 | Ross [40%] | 16h | 16h |
| 33 | 1.2.3.2.4 | Vacancy | 5d | 2012-02-13 A | 2012-02-17 A |  | 100% |  |  | start no earlier than 2012-02-13 | Janet | 40h | 40h |
| 34 | 1.2.3.2.5 | Early Return | 5d | 2012-02-13 A | 2012-02-17 A |  | 100% |  |  | start no earlier than 2012-02-13 | Ross | 40h | 40h |
| 35 | 1.2.3.2.6 | Waiting List | 5d | 2012-02-13 A | 2012-02-17 A |  | 100% |  |  | start no earlier than 2012-02-13 | Janet | 40h | 40h |
| 36 | 1.2.3.2.7 | Front Desk | 5d | 2012-02-13 A | 2012-02-17 A |  | 100% |  |  | start no earlier than 2012-02-13 | Ross | 40h | 40h |
| 37 | 1.2.3.3 | Housing SISTIM Functionality on Housing | 8d | 2012-02-21 A | 2012-03-01 A |  | 100% |  |  | start no earlier than 2012-02-21 | Ross | 64h | 64h |
| 38 | 1.2.3.4 | Housing MITSIS Functionality on Housing | 8d | 2012-02-21 A | 2012-03-01 A |  | 100% |  |  | start no earlier than 2012-02-21 | Janet | 64h | 64h |
| 39 | 1.2.3.5 | **Housing Stakeholder - HFS Accounting (David Bull's Group)** | 5d | 2012-03-05 A | 2012-03-09 A | 38FS+1d | 100% |  |  |  |  | 240h | 240h |
| 40 | 1.2.3.5.1 | Discuss systems/applications/process flow | 5d | 2012-03-05 A | 2012-03-09 A |  | 100% |  |  |  | Janet | 40h | 40h |
| 41 | 1.2.3.5.2 | Discuss process calendar | 5d | 2012-03-05 A | 2012-03-09 A |  | 100% |  |  |  | Janet | 40h | 40h |
| 42 | 1.2.3.5.3 | Walkthrough of digital Building/Room Setup & Maintenance | 5d | 2012-03-05 A | 2012-03-09 A |  | 100% |  |  |  | Janet | 40h | 40h |
| 43 | 1.2.3.5.4 | Walkthrough of Room Rate Codes Setup & Maintenance | 5d | 2012-03-05 A | 2012-03-09 A |  | 100% |  |  |  | Janet | 40h | 40h |
| 44 | 1.2.3.5.5 | Analysis/review of OTF process | 5d | 2012-03-05 A | 2012-03-09 A |  | 100% |  |  |  | Janet | 40h | 40h |
| 45 | 1.2.3.5.6 | Discuss functionality/efficiency/information gaps in current assessment & OTF process | 5d | 2012-03-05 A | 2012-03-09 A |  | 100% |  |  |  | Janet | 40h | 40h |
| 46 | 1.2.3.6 | **Housing Stakeholder - Student Financial Services** | 5d | 2012-03-13 A | 2012-03-19 A | 39FS+1d | 100% |  |  |  |  | 48h | 48h |
| 47 | 1.2.3.6.1 | Assess primary users/roles | 5d | 2012-03-13 A | 2012-03-19 A |  | 100% |  |  |  | Ross [40%] | 16h | 16h |
| 48 | 1.2.3.6.2 | Discuss systems/process flow | 5d | 2012-03-13 A | 2012-03-19 A |  | 100% |  |  |  | Ross [40%] | 16h | 16h |
| 49 | 1.2.3.6.3 | Discuss process calendar | 5d | 2012-03-13 A | 2012-03-19 A |  | 100% |  |  |  | Ross [40%] | 16h | 16h |
| 50 | 1.2.3.7 | **Housing Stakeholder - Registrar** | 5d | 2012-03-21 A | 2012-03-27 A | 46FS+1d | 100% |  |  |  |  | 120h | 120h |
| 51 | 1.2.3.7.1 | Evaluate scope of affected data/process/systems | 5d | 2012-03-21 A | 2012-03-27 A |  | 100% |  |  |  | Janet | 40h | 40h |
| 52 | 1.2.3.7.2 | Examine dataflow for MITSIS Directory information | 5d | 2012-03-21 A | 2012-03-27 A |  | 100% |  |  |  | Janet | 40h | 40h |
| 53 | 1.2.3.7.3 | Examine current supporting processes & functionality | 5d | 2012-03-21 A | 2012-03-27 A |  | 100% |  |  |  | Janet | 40h | 40h |
| 54 | 1.2.3.8 | Housing Stakeholders - Card Office / SEMO I | 1d | 2012-03-23 A | 2012-03-23 A |  | 100% |  |  | start no earlier than 2012-03-23 | Ross [40%] | 3.2h | 3.2h |
| 55 | 1.2.3.9 | Housing Stakeholders - Campus Dining | 1d | 2012-04-04 A | 2012-04-04 A |  | 100% |  |  | start no earlier than 2012-04-04 | Ross [40%] | 3.2h | 3.2h |
| 56 | 1.2.3.10 | Housing Stakeholders - Tech Cash | 1d | 2012-04-04 A | 2012-04-04 A |  | 100% |  |  | start no earlier than 2012-04-04 | Janet [40%] | 3.2h | 3.2h |
| 57 | 1.2.3.11 | UG House Managers | 1d | 2012-04-12 A | 2012-04-12 A |  | 100% |  |  | start no earlier than 2012-04-12 | Ross [40%] | 3.2h | 3.2h |
| 58 | 1.2.3.12 | GRAD House Managers | 1d | 2012-04-17 A | 2012-04-17 A |  | 100% |  |  | start no earlier than 2012-04-17 | Janet [40%] | 3.2h | 3.2h |
| 59 | 1.2.3.13 | Housing Stakeholders - Card Office / SEMO II | 1d | 2012-04-23 A | 2012-04-23 A |  | 100% |  |  | start no earlier than 2012-04-23 | Janet | 8h | 8h |
| 60 | 1.2.3.14 | FSILG | 1d | 2012-05-15 | 2012-05-15 |  |  | 153d |  | start no earlier than 2012-05-15 | Janet [40%] | 3.2h |  |
| 61 | 1.2.3.15 | Dean On Call | 1d | 2012-05-09 | 2012-05-09 |  |  | 147d | 0d | start no earlier than 2012-05-09 |  |  |  |

| ID | WBS | Task | Type | Duration | Start | Finish | Predecessors | Complete | Remaining | Total slack | Free slack | Constraint | Resources | Work | Actual work |
| --- | --- | --- | --- | --- | --- | --- | --- | --- | --- | --- | --- | --- | --- | --- | --- |
| 62 | 1.2.3.16 | **CBORD** |  | 10d | 2012-05-10 | 2012-05-23 | 61 |  |  | 147d |  |  |  | 96h |  |
| 63 | 1.2.3.16.1 | Digital Building / Room Setup & Maintenance |  | 10d | 2012-05-10 | 2012-05-23 |  |  |  | 132d |  | start no earlier than 2012-01-23 | Ross [40%] | 32h |  |
| 64 | 1.2.3.16.2 | Room Rate Code Setup & Maintenance |  | 10d | 2012-05-10 | 2012-05-23 |  |  |  | 147d |  | start no earlier than 2012-03-05 | Ross [40%] | 32h |  |
| 65 | 1.2.3.16.3 | Current Security, Roles & Authorization, and structures for housing applications |  | 10d | 2012-05-10 | 2012-05-23 |  |  |  | 147d |  | start no earlier than 2012-03-05 | Ross [40%] | 32h |  |
| 66 | 1.2.4 | **Discovery Phase Documentation** |  | 77d | 2012-04-09 A | 2012-07-24 |  | 22% | 59.96d | 103d |  |  |  | 546h | 89.04h |
| 67 | 1.2.4.1 | **As-Is Business Process Descriptions** |  | 25d | 2012-04-09 A | 2012-05-11 |  | 42% | 14.58d | 155d |  |  |  | 134.4h | 48h |
| 68 | 1.2.4.1.1 | Undergraduate Process - Internal review |  | 15d | 2012-04-09 A | 2012-04-27 |  | 50% | 7.5d | 18d | 4d | finish no earlier than 2012-04-27 | Ross [40%] | 48h | 24h |
| 69 | 1.2.4.1.2 | Graduate Process - Internal review |  | 15d | 2012-04-09 A | 2012-04-27 |  | 50% | 7.5d | 18d | 4d | finish no earlier than 2012-04-27 | Janet [40%] | 48h | 24h |
| 70 | 1.2.4.1.3 | Present Draft Versions to Project Sponsor |  | 1d | 2012-05-04 | 2012-05-04 | 68, 69 |  |  | 14d | 0d | start no earlier than 2012-05-04 | Ross [40%]; Janet [40%] | 6.4h |  |
| 71 | 1.2.4.1.4 | Updated completed versions after feedback from Project Sponsors |  | 5d | 2012-05-07 | 2012-05-11 | 70, 68, 69 |  |  | 155d | 0d | start no earlier than 2012-04-30 | Ross [40%]; Janet [40%] | 32h |  |
| 72 | 1.2.4.1.5 | As-Is Busines Process Documentation completed | milestone | 0d | 2012-05-11 | 2012-05-11 | 71 |  |  | 155d |  |  |  |  |  |
| 73 | 1.2.4.2 | **As-Is Process Maps (Visual Micrografx Process Maps)** |  | 31d | 2012-05-07 | 2012-06-18 | 70 |  |  | 0d |  |  |  | 147.2h |  |
| 74 | 1.2.4.2.1 | Graduate Students - Internal review |  | 17d | 2012-05-07 | 2012-05-29 |  |  |  | 14d |  | finish no earlier than 2012-05-24 | Janet [40%] | 54.4h |  |
| 75 | 1.2.4.2.2 | Undergraduate Students |  | 17d | 2012-05-07 | 2012-05-29 |  |  |  | 14d |  | finish no earlier than 2012-05-24 | Ross [40%] | 54.4h |  |
| 76 | 1.2.4.2.3 | Present Draft Versions to Project Sponsor |  | 1d | 2012-06-11 | 2012-06-11 |  |  |  | 0d |  | start no earlier than 2012-06-11 | Janet [40%]; Ross [40%] | 6.4h |  |
| 77 | 1.2.4.2.4 | Updated completed versions after feedback from Project Sponsors |  | 5d | 2012-06-12 | 2012-06-18 | 76 |  |  | 0d |  | start no earlier than 2012-05-29 | Janet [40%]; Ross [40%] | 32h |  |
| 78 | 1.2.4.2.5 | As-Is Process Maps completed | milestone | 0d | 2012-06-18 | 2012-06-18 | 77 |  |  | 0d |  |  |  |  |  |
| 79 | 1.2.4.3 | **System Diagram (IS&T)** |  | 39d | 2012-05-31 A | 2012-07-24 | 73 | 26% | 28.83d | 0d |  |  | Ross [44%] | 264.4h | 41.04h |
| 80 | 1.2.4.3.1 | High Level Picture |  | 20d | 2012-05-31 A | 2012-07-02 |  | 50% | 10d | 16d |  |  | Ross [40%] | 64h | 32h |
| 81 | 1.2.4.3.2 | Details - with Feeds, Interfaces, |  | 20d | 2012-06-19 A | 2012-07-16 |  | 10% | 18d | 0d |  |  | Ross [40%] | 64h | 6.4h |
| 82 | 1.2.4.3.3 | Present Draft Versions to Project Sponsor |  | 1d | 2012-07-17 | 2012-07-17 | 81 |  |  | 0d |  |  |  |  |  |
| 83 | 1.2.4.3.4 | Updated completed versions after feedback from Project Sponsors |  | 5d | 2012-07-18 | 2012-07-24 | 82 |  |  | 0d |  |  |  |  |  |
| 84 | 1.2.4.3.5 | As-Is System Diagram completed | milestone | 0d | 2012-07-24 | 2012-07-24 | 83 |  |  | 0d |  |  |  |  |  |
| 85 | 1.2.5 | Review with Project Team, Stakeholders |  | 3d | 2012-07-25 | 2012-07-27 | 79 |  |  | 0d |  |  |  |  |  |
| 86 | 1.2.6 | Discovery Phase Completed | milestone | 0d | 2012-07-27 | 2012-07-27 | 85 |  |  | 0d |  |  |  |  |  |
| 87 | 1.3 | Define Phase |  | 50d | 2012-07-30 | 2012-10-05 | 86 |  |  | 0d |  |  |  |  |  |
| 88 | 1.4 | Design Phase |  | 50d | 2012-10-08 | 2012-12-14 | 87 |  |  | 0d |  |  |  |  |  |

Notes:
- 73: Need to show calendar and stakeholders
